# Commercial Construction_HPP_lesson 2_2

Schedule from MS Project, 2016-08-15 to 2017-05-17.

## Calendars

- Standard: Mon-Fri 08:00-12:00, 13:00-17:00; Sat-Sun off.

## Schedule

| ID | WBS | Task | Type | Duration | Start | Finish | Predecessors | Total slack | Free slack |
| --- | --- | --- | --- | --- | --- | --- | --- | --- | --- |
| 1 | 1 | **General Conditions** |  | 21.75d | 2016-08-15 | 2016-09-13 |  | 166.62d | 0d |
| 2 | 1.1 | Receive notice to proceed and sign contract |  | 3d | 2016-08-15 | 2016-08-17 |  | 166.62d | 0d |
| 3 | 1.2 | Submit bond and insurance documents |  | 2d | 2016-08-18 | 2016-08-19 | 2 | 166.62d | 0d |
| 4 | 1.3 | Prepare and submit project schedule |  | 2d | 2016-08-22 | 2016-08-23 | 3 | 166.62d | 0d |
| 5 | 1.4 | Obtain building permits |  | 4d | 2016-08-24 | 2016-08-29 | 4 | 166.62d | 0d |
| 6 | 1.5 | Submit preliminary shop drawings |  | 2w | 2016-08-30 | 2016-09-12 | 5 | 166.62d | 0d |
| 7 | 1.6 | Submit monthly requests for payment |  | 6h | 2016-09-13 | 2016-09-13 | 6 | 175.88d | 0d |
| 8 | 1.7 | Final General Condition | milestone | 0d | 2016-09-13 | 2016-09-13 | 7 | 175.88d | 0d |
| 9 | 2 | **Long Lead Procurement** |  | 29.25d | 2016-08-30 | 2016-10-10 |  | 140.38d | 0d |
| 10 | 2.1 | Submit shop drawings and order long lead items - steel |  | 2w | 2016-08-30 | 2016-09-13 | 7FF | 140.38d | 0d |
| 11 | 2.2 | Submit shop drawings and order long lead items - roofing |  | 2w | 2016-09-13 | 2016-09-26 | 6 | 166.62d | 0d |
| 12 | 2.3 | Detail, fabricate and deliver steel |  | 4w | 2016-09-13 | 2016-10-10 | 11SS | 156.62d | 0d |
| 13 | 2.4 | Long Lead Procurement check all items | milestone | 0d | 2016-10-10 | 2016-10-10 | 12 | 156.62d | 0d |
| 14 | 2 | **Mobilize on Site** |  | 7.5d | 2016-09-13 | 2016-09-23 |  | 140.38d | 0d |
| 15 | 2.1 | Install temporary power |  | 2.5d | 2016-09-13 | 2016-09-16 | 10 | 140.38d | 0d |
| 16 | 2.2 | Set up site office |  | 3d | 2016-09-16 | 2016-09-21 | 15 | 140.38d | 0d |
| 17 | 2.3 | Prepare site - lay down yard and temporary fencing |  | 2d | 2016-09-21 | 2016-09-23 | 16 | 140.38d | 0d |
| 18 | 2.4 | Finish temporay utilities | milestone | 0d | 2016-09-23 | 2016-09-23 | 17 | 168.38d | 0d |
| 19 | 3 | **Site Grading and Utilities** |  | 28d | 2016-09-23 | 2016-11-02 |  | 140.38d | 0d |
| 20 | 3.1 | Clear and grub site |  | 3d | 2016-09-23 | 2016-09-28 | 16, 17 | 140.38d | 0d |
| 21 | 3.2 | Rough grade site (cut and fill) |  | 1w | 2016-09-28 | 2016-10-05 | 17, 20 | 140.38d | 0d |
| 22 | 3.3 | Install exterior fire line and building fire riser |  | 2w | 2016-10-05 | 2016-10-19 | 21 | 140.38d | 0d |
| 23 | 3.4 | Perform final site grading |  | 2w | 2016-10-19 | 2016-11-02 | 22 | 140.38d | 0d |
| 24 | 3.5 | Install Utilities check | milestone | 0d | 2016-11-02 | 2016-11-02 | 23 | 140.38d | 0d |

| ID | WBS | Task | Type | Duration | Start | Finish | Predecessors | Total slack | Free slack | Constraint |
| --- | --- | --- | --- | --- | --- | --- | --- | --- | --- | --- |
| 25 | 4 | **Team meeting and discussion with partners** |  | 20.25d | 2017-01-04 | 2017-02-01 |  | 75.38d | 0d |  |
| 26 | 4.1 | Team meeting and discussion with partners 1 |  | 2h | 2017-01-04 | 2017-01-04 |  | 95.38d | 0d | start no earlier than 2017-01-04 |
| 27 | 4.2 | Team meeting and discussion with partners 2 |  | 2h | 2017-01-18 | 2017-01-18 |  | 85.38d | 0d | start no earlier than 2017-01-18 |
| 28 | 4.3 | Team meeting and discussion with partners 3 |  | 2h | 2017-02-01 | 2017-02-01 |  | 75.38d | 0d | start no earlier than 2017-02-01 |
| 29 | 5 | **Foundations** |  | 19.5d | 2016-11-30 | 2016-12-27 |  | 0d |  |  |
| 30 | 5.1 | Excavate foundations |  | 2w | 2016-11-30 | 2016-12-13 |  | 0d |  | must finish on 2016-12-13 |
| 31 | 5.2 | Rough-in electric and plumbing in elevator |  | 4d | 2016-11-30 | 2016-12-05 | 30SS | 110.12d | 0d |  |
| 32 | 5.3 | Pour column piers and foundations |  | 5d | 2016-12-06 | 2016-12-12 | 31 | 110.12d | 0d |  |
| 33 | 5.4 | Pour concrete elevator walls |  | 1.5d | 2016-12-13 | 2016-12-14 | 31, 32 | 110.12d | 0d |  |
| 34 | 5.5 | Cure elevator wall concrete |  | 1d | 2016-12-14 | 2016-12-14 | 30, 33FF | 106.12d | 0d |  |
| 35 | 6.4 | Strip wall forms |  | 2d | 2016-12-22 | 2016-12-23 | 34FS+5d | 101.12d | 0d |  |
| 36 | 5.6 | Prepare and pour concrete floor in elevator pit |  | 12h | 2016-12-26 | 2016-12-27 | 35 | 101.12d | 0d |  |
| 37 | 5.7 | Foundation inspection | milestone | 0d | 2016-12-27 | 2016-12-27 | 36 | 101.12d | 0d |  |
| 38 | 6 | **Building Finishes** |  | 92d | 2016-12-27 | 2017-05-04 |  | 0d |  |  |
| 39 | 6.1 | Install millwork and wood trim |  | 3w | 2016-12-27 | 2017-01-17 | 37SS | 0.5d | 0d |  |
| 40 | 6.2 | Paint walls and woodwork |  | 1mo | 2017-01-17 | 2017-02-14 | 39 | 0.5d | 0d |  |
| 41 | 6.3 | Install conduit at ceiling plenum space |  | 2.5w | 2017-02-14 | 2017-03-02 | 40 | 0.5d | 0d |  |
| 42 | 6.5 | Install duct in ceiling plenum space |  | 3w | 2017-03-02 | 2017-03-23 | 41FS-4h | 0d |  |  |
| 43 | 6.6 | Install ceiling grid |  | 2w | 2017-03-23 | 2017-04-06 | 42 | 0d |  |  |
| 44 | 6.7 | Install ceiling tile |  | 2w | 2017-04-06 | 2017-04-20 | 43 | 0d |  |  |
| 45 | 6.8 | Hang wallpaper |  | 2w | 2017-04-20 | 2017-05-04 | 44 | 0d |  |  |
| 46 | 6.9 | Building Finishes inspection | milestone | 0d | 2017-05-04 | 2017-05-04 | 45 | 0d |  |  |
| 47 | 7 | **Final Clean-up and Occupancy** |  | 7d | 2017-05-04 | 2017-05-15 |  | 0d |  |  |
| 48 | 7.1 | Install hard tile flooring in common areas |  | 1w | 2017-05-04 | 2017-05-11 | 46 | 0d |  |  |
| 49 | 7.2 | Remove debris from building and do final clean-up |  | 1d | 2017-05-11 | 2017-05-12 | 48 | 0d |  |  |
| 50 | 7.3 | Substantial completion date |  | 1d | 2017-05-12 | 2017-05-15 | 49 | 2.12d | 0d |  |

| ID | WBS | Task | Duration | Start | Finish | Predecessors | Total slack | Free slack | Constraint |
| --- | --- | --- | --- | --- | --- | --- | --- | --- | --- |
| 51 | 8 | **Complete Final Inspections** | 1.31d | 2017-05-12 | 2017-05-15 |  | 0d |  |  |
| 52 | 8.1 | Complete elevator inspection and certification | 0.5d | 2017-05-12 | 2017-05-12 | 49 | 0d |  |  |
| 53 | 8.2 | Perform architect's inspection | 5h | 2017-05-15 | 2017-05-15 | 52 | 0d |  |  |
| 54 | 8.3 | Perform Fire Marshal's inspection | 90min | 2017-05-15 | 2017-05-15 | 53 | 0.81d | 0d |  |
| 55 | 9 | Issue final completion documents including warranties | 1d | 2017-05-15 | 2017-05-16 | 53 | 0d |  | start no earlier than 2017-01-09 |
| 56 | 10 | Issue final request for payment | 1d | 2017-05-16 | 2017-05-17 | 54, 55 | 0d |  |  |
