# Commercial Construction

Schedule from MS Project, 2016-08-22 to 2017-03-17, costs in $, A marks actual dates.

## Calendars

- Standard: Mon-Fri 08:00-12:00, 13:00-17:00; Sat-Sun off. Exceptions (off unless hours are given): 2016-12-24 to 2016-12-27 (Christmas), 2017-01-01 to 2017-01-02 (New Year).
- End of Week: Mon-Thu off; Fri 08:00-12:00, 13:00-17:00; Sat-Sun off. Exceptions (off unless hours are given): 2016-12-24 to 2016-12-27 (Christmas), 2017-01-01 to 2017-01-02 (New Year).

## Resources

| Resource | Unit | Rate | Cost per use | Notes |
| --- | --- | --- | --- | --- |
| G.C. General Management |  | 60 |  |  |
| Elevator Contractor Management |  | 50 |  |  |
| Plumbing Contractor Management |  | 50 |  |  |
| Electric Contractor Management |  | 50 |  |  |
| Roofing Contractor Management |  | 50 |  |  |
| G.C. Project Management |  | 50 |  |  |
| Steel Erection Contractor Management |  | 50 |  |  |
| Concrete | ton | 500 | 100 |  |
| Painting Material | liter | 5 |  |  |
| HVAC Contractor Management |  | 50 |  |  |
| Electric Contractor |  | 40 |  |  |
| Plumbing Contractor |  | 40 |  |  |
| G.C. Survey Crew |  | 30 |  |  |
| Site Grading Contractor |  | 40 |  |  |
| G.C. Rough Carpenter Crew |  | 30 |  |  |
| G.C. Concrete Crew |  | 30 |  |  |
| G.C. Labor Crew |  | 30 |  |  |
| Elevator Contractor |  | 40 |  |  |
| G.C. Finish Carpenter Crew |  | 30 |  |  |
| HVAC Contractor |  | 40 |  |  |
| Drywall Contractor |  | 40 |  |  |
| Painting Contractor |  | 50 |  | pay rate was adjusted |
| Carpet Contractor |  | 40 |  |  |
| Landscape Contractor |  | 40 |  |  |
| Tile Contractor |  | 40 |  |  |
| G.C. Superintendent |  | 30 |  |  |
| G.C Scheduler |  | 35 |  |  |
| G.C Procurement |  | 35 |  |  |
| Steel Erection Contractor |  | 40 |  |  |
| Paving Contractor |  | 40 |  |  |
| G.C Accounting |  | 45 |  |  |

## Schedule

| ID | WBS | Task | Type | Duration | Start | Finish | Predecessors | Complete | Remaining | Baseline start | Baseline finish | Baseline duration | Total slack | Free slack | Calendar | Resources | Work | Actual work | Cost | Baseline cost | Actual cost |
| --- | --- | --- | --- | --- | --- | --- | --- | --- | --- | --- | --- | --- | --- | --- | --- | --- | --- | --- | --- | --- | --- |
| 1 | 1 | **General Conditions** |  | 24.75d | 2016-08-22 A | 2016-09-23 |  | 50% | 12.23d | 2016-08-22 | 2016-09-23 | 24.75d | 25.25d | 0d |  |  | 176h | 96h | 8,100 | 8,100 | 4,600 |
| 2 | 1.1 | Receive notice to proceed and sign contract |  | 3d | 2016-08-22 A | 2016-08-24 A |  | 100% |  | 2016-08-22 | 2016-08-24 | 3d |  |  |  | G.C. General Management | 24h | 24h | 1,440 | 1,440 | 1,440 |
| 3 | 1.2 | Submit bond and insurance documents |  | 2d | 2016-08-25 A | 2016-08-26 A | 2 | 100% |  | 2016-08-25 | 2016-08-26 | 2d |  |  |  | G.C. Project Management; G.C. General Management [25%] | 20h | 20h | 1,040 | 1,040 | 1,040 |
| 4 | 1.3 | Prepare, review and submit project schedule |  | 2d | 2016-08-29 A | 2016-08-30 A | 3 | 100% |  | 2016-08-29 | 2016-08-30 | 2d |  |  |  | G.C. Project Management [25%]; G.C Scheduler | 20h | 20h | 760 | 760 | 760 |
| 5 | 1.4 | Obtain building permits |  | 4d | 2016-08-31 A | 2016-09-05 A | 4 | 100% |  | 2016-08-31 | 2016-09-05 | 4d |  |  |  | G.C. Project Management [50%]; G.C Procurement [50%] | 32h | 32h | 1,360 | 1,360 | 1,360 |
| 6 | 1.5 | Submit preliminary shop drawings |  | 2w | 2016-09-06 | 2016-09-19 | 5 |  |  | 2016-09-06 | 2016-09-19 | 2w | 116d | 0d |  | G.C. Project Management [50%]; G.C Procurement [50%] | 80h |  | 3,400 | 3,400 |  |
| 7 | 1.6 | Submit monthly requests for payment |  | 6h | 2016-09-23 | 2016-09-23 | 6 |  |  | 2016-09-23 | 2016-09-23 | 6h | 25.25d | 0d | End of Week |  |  |  | 100 | 100 |  |
| 8 | 1.7 | Final General Condition | milestone | 0d | 2016-09-23 | 2016-09-23 | 7 |  |  | 2016-09-23 | 2016-09-23 | 0d | 122.25d | 0d |  |  |  |  |  |  |  |
| 9 | 2 | **Long Lead Procurement** |  | 26.25d | 2016-09-09 A | 2016-10-17 |  | 25% | 19.69d | 2016-09-09 | 2016-10-17 | 26.25d | 13.75d | 0d |  |  | 320h | 80h | 15,200 | 15,200 | 4,000 |
| 10 | 2.1 | Submit shop drawings and order long lead items - steel |  | 2w | 2016-09-09 A | 2016-09-23 A | 7FF | 100% |  | 2016-09-09 | 2016-09-23 | 2w |  |  |  | Steel Erection Contractor Management | 80h | 80h | 4,000 | 4,000 | 4,000 |
| 11 | 2.2 | Submit shop drawings and order long lead items - roofing |  | 2w | 2016-09-20 | 2016-10-03 | 6 |  |  | 2016-09-20 | 2016-10-03 | 2w | 116d | 0d |  | Roofing Contractor Management | 80h |  | 4,000 | 4,000 |  |
| 12 | 2.3 | Detail, fabricate and deliver steel |  | 4w | 2016-09-20 | 2016-10-17 | 11SS |  |  | 2016-09-20 | 2016-10-17 | 4w | 106d | 0d |  | Steel Erection Contractor Management [50%]; Steel Erection Contractor [50%] | 160h |  | 7,200 | 7,200 |  |
| 13 | 2.4 | Long Lead Procurement check all items | milestone | 0d | 2016-10-17 | 2016-10-17 | 12 |  |  | 2016-10-17 | 2016-10-17 | 0d | 106d | 0d |  |  |  |  |  |  |  |
| 14 | 2 | **Mobilize on Site** |  | 10.25d | 2016-09-23 A | 2016-10-07 |  | 8% | 9.4d | 2016-09-23 | 2016-10-07 | 10.25d | 11d | 0d |  |  | 64h | 5h | 2,280 | 2,280 | 200 |
| 15 | 2.1 | Install temporary power |  | 2.5d | 2016-09-23 A | 2016-09-28 | 10 | 25% | 1.88d | 2016-09-23 | 2016-09-28 | 2.5d | 13.75d | 0d |  | Electric Contractor | 20h | 5h | 800 | 800 | 200 |
| 16 | 2.2 | Set up site office |  | 3d | 2016-09-28 | 2016-10-03 | 15 |  |  | 2016-09-28 | 2016-10-03 | 3d | 13.75d | 0d |  | G.C. Superintendent; G.C. Labor Crew [10%] | 26.4h |  | 792 | 792 |  |
| 17 | 2.3 | Prepare site - lay down yard and temporary fencing |  | 2d | 2016-10-06 | 2016-10-07 | 16 |  |  | 2016-10-06 | 2016-10-07 | 2d | 11d | 0d |  | Site Grading Contractor; G.C. Labor Crew [10%] | 17.6h |  | 688 | 688 |  |
| 18 | 2.4 | Finish temporay utilities | milestone | 0d | 2016-10-07 | 2016-10-07 | 17 |  |  | 2016-10-07 | 2016-10-07 | 0d | 112d | 0d |  |  |  |  |  |  |  |
| 19 | 3 | **Site Grading and Utilities** |  | 28d | 2016-10-10 | 2016-11-16 |  |  |  | 2016-10-10 | 2016-11-16 | 28d | 11d | 0d |  |  | 224h |  | 8,960 | 8,960 |  |
| 20 | 3.1 | Clear and grub site |  | 3d | 2016-10-10 | 2016-10-12 | 16, 17 |  |  | 2016-10-10 | 2016-10-12 | 3d | 11d | 0d |  | Site Grading Contractor | 24h |  | 960 | 960 |  |
| 21 | 3.2 | Rough grade site (cut and fill) |  | 1w | 2016-10-13 | 2016-10-19 | 17, 20 |  |  | 2016-10-13 | 2016-10-19 | 1w | 11d | 0d |  | Site Grading Contractor | 40h |  | 1,600 | 1,600 |  |
| 22 | 3.3 | Install exterior fire line and building fire riser |  | 2w | 2016-10-20 | 2016-11-02 | 21 |  |  | 2016-10-20 | 2016-11-02 | 2w | 11d | 0d |  | Plumbing Contractor | 80h |  | 3,200 | 3,200 |  |
| 23 | 3.4 | Perform final site grading |  | 2w | 2016-11-03 | 2016-11-16 | 22 |  |  | 2016-11-03 | 2016-11-16 | 2w | 11d | 0d |  | Site Grading Contractor | 80h |  | 3,200 | 3,200 |  |
| 24 | 3.5 | Install Utilities check | milestone | 0d | 2016-11-16 | 2016-11-16 | 23 |  |  | 2016-11-16 | 2016-11-16 | 0d | 11d | 0d |  |  |  |  |  |  |  |

Notes:
- 4: task completed; some feedback may be useful

| ID | WBS | Task | Type | Duration | Start | Finish | Predecessors | Complete | Remaining | Baseline start | Baseline finish | Baseline duration | Total slack | Free slack | Constraint | Deadline | Resources | Work | Actual work | Cost | Baseline cost | Actual cost |
| --- | --- | --- | --- | --- | --- | --- | --- | --- | --- | --- | --- | --- | --- | --- | --- | --- | --- | --- | --- | --- | --- | --- |
| 25 | 4 | **Team meeting and discussion with partners** |  | 20.25d | 2017-01-04 A | 2017-02-01 A |  | 100% |  | 2017-01-04 | 2017-02-01 | 20.25d |  |  |  |  |  |  |  |  |  |  |
| 26 | 4.1 | Team meeting and discussion with partners 1 |  | 2h | 2017-01-04 A | 2017-01-04 A |  | 100% |  | 2017-01-04 | 2017-01-04 | 2h |  |  | start no earlier than 2017-01-04 |  |  |  |  |  |  |  |
| 27 | 4.2 | Team meeting and discussion with partners 2 |  | 2h | 2017-01-18 A | 2017-01-18 A |  | 100% |  | 2017-01-18 | 2017-01-18 | 2h |  |  | start no earlier than 2017-01-18 |  |  |  |  |  |  |  |
| 28 | 4.3 | Team meeting and discussion with partners 3 |  | 2h | 2017-02-01 A | 2017-02-01 A |  | 100% |  | 2017-02-01 | 2017-02-01 | 2h |  |  | start no earlier than 2017-02-01 |  |  |  |  |  |  |  |
| 29 | 5 | **Foundations** |  | 26.5d | 2016-11-17 A | 2016-12-23 |  | 36% | 16.86d | 2016-11-17 | 2016-12-16 | 21.5d | 0d |  |  |  |  | 283.2h | 120h | 10,136 | 10,136 | 4,000 |
| 30 | 5.1 | Excavate foundations |  | 2w | 2016-11-17 A | 2016-11-30 A | 24 | 100% |  | 2016-11-17 | 2016-11-30 | 2w |  |  |  | 2016-12-20 | G.C. Labor Crew; Site Grading Contractor [50%] | 120h | 120h | 4,000 | 4,000 | 4,000 |
| 31 | 5.2 | Rough-in electric and plumbing in elevator |  | 4d | 2016-11-24 | 2016-11-29 | 30SS |  |  | 2016-11-17 | 2016-11-22 | 4d | 67d | 0d | start no earlier than 2016-11-24 |  | Plumbing Contractor; Electric Contractor | 64h |  | 2,560 | 2,560 |  |
| 32 | 5.3 | Pour column piers and foundations |  | 5d | 2016-11-30 | 2016-12-06 | 31 |  |  | 2016-11-23 | 2016-11-29 | 5d | 67d | 0d |  | 2016-11-14 | G.C. Concrete Crew [150%] | 60h |  | 1,800 | 1,800 |  |
| 33 | 5.4 | Pour concrete elevator walls |  | 3d | 2016-12-07 | 2016-12-09 | 31, 32 |  |  | 2016-11-30 | 2016-12-02 | 3d | 67d | 0d |  |  | G.C. Concrete Crew; Concrete [1 ton] | 24h |  | 1,320 | 1,320 |  |
| 34 | 5.5 | Cure elevator wall concrete |  | 1d | 2016-12-09 | 2016-12-09 | 30, 33FF |  |  | 2016-12-02 | 2016-12-02 | 1d | 5d | 0d |  |  | G.C. Labor Crew [10%] | 0.8h |  | 24 | 24 |  |
| 35 | 6.4 | Strip wall forms |  | 3d | 2016-12-19 | 2016-12-21 | 34FS+5d |  |  | 2016-12-12 | 2016-12-14 | 3d | 0d |  |  |  | G.C. Labor Crew [10%] | 2.4h |  | 72 | 72 |  |
| 36 | 5.6 | Prepare and pour concrete floor in elevator pit |  | 12h | 2016-12-22 | 2016-12-23 | 35 |  |  | 2016-12-15 | 2016-12-16 | 12h | 0d |  |  |  | G.C. Concrete Crew | 12h |  | 360 | 360 |  |
| 37 | 5.7 | Foundation inspection | milestone | 0d | 2016-12-23 | 2016-12-23 | 36 |  |  | 2016-12-16 | 2016-12-16 | 0d | 0d |  |  |  |  |  |  |  |  |  |
| 38 | 6 | **Building Finishes** |  | 52.5d | 2016-12-23 A | 2017-03-10 |  | 10% | 47.25d | 2016-12-16 | 2017-05-19 | 105.75d | 0d |  |  |  |  | 740h | 80h | 30,805 | 28,405 | 2,600 |
| 39 | 6.1 | Install millwork and wood trim |  | 3w | 2016-12-23 A | 2017-01-18 | 37SS | 50% | 1.5w | 2016-12-16 | 2017-01-11 | 3w | 5d | 0d |  |  | G.C. Finish Carpenter Crew | 120h | 60h | 3,600 | 3,600 | 1,800 |
| 40 | 6.2 | Paint walls and woodwork |  | 1mo | 2017-01-18 | 2017-02-22 | 39 |  |  | 2017-01-11 | 2017-02-15 | 1mo | 4d | 0d |  |  | Painting Contractor; Painting Material [1 liter] | 160h |  | 8,005 | 6,405 |  |
| 41 | 6.3 | Install conduit at ceiling plenum space |  | 2.5w | 2017-02-22 | 2017-03-10 | 40 |  |  | 2017-02-15 | 2017-03-03 | 2.5w | 5d | 0d |  |  | Electric Contractor | 100h |  | 4,000 | 4,000 |  |
| 42 | 6.5 | Install duct in ceiling plenum space |  | 3w | 2016-12-23 | 2017-01-18 | 37 |  |  | 2017-03-03 | 2017-03-24 | 3w | 0d |  |  |  | HVAC Contractor | 120h |  | 4,800 | 4,800 |  |
| 43 | 6.6 | Install ceiling grid |  | 1w | 2017-01-18 A | 2017-01-27 | 42 | 25% | 0.75w | 2017-03-24 | 2017-04-12 | 2w | 0d |  |  |  | Drywall Contractor [200%] | 80h | 20h | 3,200 | 3,200 | 800 |
| 44 | 6.7 | Install ceiling tile |  | 2w | 2017-01-27 | 2017-02-15 | 43 |  |  | 2017-04-13 | 2017-05-03 | 2w | 0d |  |  |  | Drywall Contractor | 80h |  | 3,200 | 3,200 |  |
| 45 | 6.8 | Hang wallpaper |  | 2w | 2017-02-15 | 2017-03-03 | 44 |  |  | 2017-05-03 | 2017-05-19 | 2w | 0d |  |  |  | Painting Contractor | 80h |  | 4,000 | 3,200 |  |
| 46 | 6.9 | Building Finishes inspection | milestone | 0d | 2017-03-03 | 2017-03-03 | 45 |  |  | 2017-05-19 | 2017-05-19 | 0d | 0d |  |  |  |  |  |  |  |  |  |
| 47 | 7 | **Final Clean-up and Occupancy** |  | 7d | 2017-03-03 | 2017-03-14 |  |  |  | 2017-05-19 | 2017-05-29 | 6d | 0d |  |  |  |  | 52h |  | 2,000 | 2,000 |  |
| 48 | 7.1 | Install hard tile flooring in common areas |  | 1w | 2017-03-03 | 2017-03-10 | 46 |  |  | 2017-05-19 | 2017-05-25 | 1w | 0d |  |  |  | Tile Contractor | 40h |  | 1,600 | 1,600 |  |
| 49 | 7.2 | Remove debris from building and do final clean-up |  | 1d | 2017-03-10 | 2017-03-13 | 48 |  |  | 2017-05-25 | 2017-05-26 | 1d | 0d |  |  |  | Tile Contractor [50%] | 4h |  | 160 | 160 |  |
| 50 | 7.3 | Substantial completion date |  | 1d | 2017-03-13 | 2017-03-14 | 49 |  |  | 2017-05-26 | 2017-05-29 | 1d | 3.5d | 0d |  |  | G.C. Superintendent | 8h |  | 240 | 240 |  |

Notes:
- 25: check progress and discuss about next steps

| ID | WBS | Task | Duration | Start | Finish | Predecessors | Baseline start | Baseline finish | Baseline duration | Total slack | Free slack | Constraint | Resources | Work | Cost | Baseline cost |
| --- | --- | --- | --- | --- | --- | --- | --- | --- | --- | --- | --- | --- | --- | --- | --- | --- |
| 51 | 8 | **Complete Final Inspections** | 2.69d | 2017-03-13 | 2017-03-16 |  | 2017-05-26 | 2017-05-29 | 1.31d | 0d |  |  |  | 21.5h | 860 | 420 |
| 52 | 8.1 | Complete elevator inspection and certification | 0.5d | 2017-03-13 | 2017-03-13 | 49 | 2017-05-26 | 2017-05-26 | 0.5d | 0d |  |  | Elevator Contractor | 4h | 160 | 160 |
| 53 | 8.2 | Perform architect's inspection | 2d | 2017-03-14 | 2017-03-15 | 52 | 2017-05-26 | 2017-05-29 | 5h | 0d |  |  | G.C. Superintendent [50%]; G.C. Project Management [50%] | 16h | 640 | 200 |
| 54 | 8.3 | Perform Fire Marshal's inspection | 90min | 2017-03-16 | 2017-03-16 | 53 | 2017-05-29 | 2017-05-29 | 90min | 0.81d | 0d |  | G.C. Superintendent [50%]; G.C. Project Management [50%] | 1.5h | 60 | 60 |
| 55 | 9 | Issue final completion documents including warranties | 1d | 2017-03-16 | 2017-03-16 | 53 | 2017-05-29 | 2017-05-30 | 1d | 0d |  | start no earlier than 2017-01-09 | G.C. Project Management | 8h | 400 | 400 |
| 56 | 10 | Issue final request for payment | 1d | 2017-03-17 | 2017-03-17 | 54, 55 | 2017-05-30 | 2017-05-31 | 1d | 0d |  |  | G.C. Project Management [33%]; G.C Accounting [33%]; G.C. General Management [33%] | 7.92h | 409.2 | 409.2 |
